# GANTT

Schedule from MS Project, 2018-02-28 to 2018-06-19, status date 2018-04-06, 7 hours a day, A marks actual dates.

## Calendars

- Standard: Mon-Fri 09:00-12:00, 14:00-18:00; Sat-Sun off. Exceptions (off unless hours are given): 2018-03-26 to 2018-03-30 (Easter Holidays), 2018-05-07 to 2018-05-11 (Student Week).

## Resources

| Resource | Rate |
| --- | --- |
| Damien |  |
| Maarten |  |
| Maria |  |
| Moustafa |  |
| Wouter |  |
| Arduino |  |
| Dust sensor |  |
| BME 280 |  |
| OLED |  |
| PIR |  |
| Battery |  |
| Breadboard |  |
| Wire cables | 5.5 |
| Green LED | 1.6 |
| Red LED | 1.6 |
| White LED | 1.6 |
| Solar Pannel | 25.8 |
| Wood Batten | 3.99 |
| Screw | 8.99 |
| Galvanised support | 3.98 |
| Mesh Box | 10 |
| PVC Pannel | 12.99 |
| Wood Pannel | 2.99 |

## Schedule

| ID | WBS | Task | Type | Duration | Start | Finish | Predecessors | Complete | Remaining | Baseline start | Baseline finish | Baseline duration | Total slack | Free slack | Deadline | Resources | Work | Actual work |
| --- | --- | --- | --- | --- | --- | --- | --- | --- | --- | --- | --- | --- | --- | --- | --- | --- | --- | --- |
| 1 | 1 | **Multipurpose Urban Equipment** |  | 70d | 2018-02-28 A | 2018-06-19 |  | 13% | 60.67d | 2018-02-28 | 2018-06-19 | 70d | 0d |  |  |  | 1775.55h | 578.38h |
| 2 | 1.1 | **HLD - High Level Definition** |  | 3.5d | 2018-02-28 A | 2018-03-05 |  | 79% | 0.75d | 2018-02-28 | 2018-03-05 | 3.5d | 0d |  |  |  | 122.5h | 96.25h |
| 3 | 1.1.1 | **Research** |  | 1.5d | 2018-02-28 A | 2018-03-01 |  | 50% | 0.75d | 2018-02-28 | 2018-03-01 | 1.5d | 2d |  |  |  | 52.5h | 26.25h |
| 4 | 1.1.1.1 | Market Research |  | 1d | 2018-02-28 A | 2018-02-28 |  | 50% | 0.5d | 2018-02-28 | 2018-02-28 | 1d | 2.5d |  |  | Damien; Maarten; Maria; Moustafa; Wouter | 35h | 17.5h |
| 5 | 1.1.1.2 | Technical Research |  | 0.5d | 2018-03-01 A | 2018-03-01 |  | 50% | 0.25d | 2018-03-01 | 2018-03-01 | 0.5d | 2d |  |  | Damien; Maarten; Maria; Moustafa; Wouter | 17.5h | 8.75h |
| 6 | 1.1.2 | **Planning** |  | 2d | 2018-03-01 A | 2018-03-05 A | 3 | 100% |  | 2018-03-01 | 2018-03-05 | 2d |  |  |  |  | 70h | 70h |
| 7 | 1.1.2.1 | Task Identification |  | 0.5d | 2018-03-01 A | 2018-03-01 A |  | 100% |  | 2018-03-01 | 2018-03-01 | 0.5d |  |  |  | Damien; Maarten; Maria; Moustafa; Wouter | 17.5h | 17.5h |
| 8 | 1.1.2.2 | Task Allocation |  | 0.5d | 2018-03-02 A | 2018-03-02 A | 7 | 100% |  | 2018-03-02 | 2018-03-02 | 0.5d |  |  |  | Damien; Maarten; Maria; Moustafa; Wouter | 17.5h | 17.5h |
| 9 | 1.1.2.3 | Gantt Chart |  | 1d | 2018-03-02 A | 2018-03-05 A | 8 | 100% |  | 2018-03-02 | 2018-03-05 | 1d |  |  |  | Damien; Maarten; Maria; Moustafa; Wouter | 35h | 35h |
| 10 | 1.1.2.4 | Deliver project plan | milestone | 0d | 2018-03-05 A | 2018-03-05 A | 7, 8, 9 | 100% |  | 2018-03-05 | 2018-03-05 | 0d |  |  | 2018-03-05 |  |  |  |
| 11 | 1.2 | **LLD - Low Level Definition** |  | 8d | 2018-03-05 A | 2018-03-15 | 2 | 89% | 0.86d | 2018-03-05 | 2018-03-15 | 8d | 0d |  |  |  | 280h | 261.62h |
| 12 | 1.2.1 | **BlackBox** |  | 5d | 2018-03-05 A | 2018-03-12 A |  | 100% |  | 2018-03-05 | 2018-03-12 | 5d |  |  |  |  | 175h | 175h |
| 13 | 1.2.1.1 | BlackBox Diagrams |  | 2d | 2018-03-05 A | 2018-03-07 A |  | 100% |  | 2018-03-05 | 2018-03-07 | 2d |  |  |  | Damien; Maarten; Maria; Moustafa; Wouter | 70h | 70h |
| 14 | 1.2.1.2 | Structural Drafts |  | 3d | 2018-03-07 A | 2018-03-12 A | 13 | 100% |  | 2018-03-07 | 2018-03-12 | 3d |  |  |  | Damien; Maarten; Maria; Moustafa; Wouter | 105h | 105h |
| 15 | 1.2.1.3 | Deliver Blackbox | milestone | 0d | 2018-03-12 A | 2018-03-12 A | 13, 14 | 100% |  | 2018-03-12 | 2018-03-12 | 0d |  |  | 2018-03-12 |  |  |  |
| 16 | 1.2.2 | **Detailed Design** |  | 3d | 2018-03-12 A | 2018-03-15 | 12 | 83% | 0.5d | 2018-03-12 | 2018-03-15 | 3d | 0d |  |  |  | 105h | 86.62h |
| 17 | 1.2.2.1 | Detailed Schematics |  | 3d | 2018-03-12 A | 2018-03-15 A |  | 100% |  | 2018-03-12 | 2018-03-15 | 3d |  |  |  | Damien [75%]; Maarten | 36.75h | 36.75h |
| 18 | 1.2.2.2 | Structural Drawings |  | 3d | 2018-03-12 A | 2018-03-15 |  | 50% | 1.5d | 2018-03-12 | 2018-03-15 | 3d | 0d |  |  | Maria; Wouter [75%] | 36.75h | 18.38h |
| 19 | 1.2.2.3 | CardBoard Model |  | 3d | 2018-03-12 A | 2018-03-15 A |  | 100% |  | 2018-03-12 | 2018-03-15 | 3d |  |  |  | Damien [25%]; Moustafa; Wouter [25%] | 31.5h | 31.5h |
| 20 | 1.2.2.4 | Deliver Detailed Design | milestone | 0d | 2018-03-15 A | 2018-03-15 | 12, 17, 18, 19 | 50% | 0d | 2018-03-15 | 2018-03-15 | 0d | 0d |  | 2018-03-23 |  |  |  |
| 21 | 1.3 | **Material & Budget** |  | 8.5d | 2018-03-15 A | 2018-04-03 | 11 | 86% | 1.21d | 2018-03-15 | 2018-04-03 | 8.5d | 1d |  | 2018-04-04 |  | 220.5h | 189h |
| 22 | 1.3.1 | Selection Material & Components |  | 5d | 2018-03-15 A | 2018-03-22 A |  | 100% |  | 2018-03-15 | 2018-03-22 | 5d |  |  |  | Damien [90%]; Maarten [90%]; Maria [90%]; Moustafa [90%]; Wouter [90%] | 157.5h | 157.5h |
| 23 | 1.3.2 | Cost Calculations |  | 2d | 2018-04-02 A | 2018-04-03 |  | 50% | 1d | 2018-04-02 | 2018-04-03 | 2d | 1d |  |  | Damien [90%]; Maarten [90%]; Maria [90%]; Moustafa [90%]; Wouter [90%] | 63h | 31.5h |
| 24 | 1.4 | **Interim** |  | 8d | 2018-04-04 A | 2018-04-16 |  | 13% | 7d | 2018-04-04 | 2018-04-16 | 8d | 3.5d | 0d |  |  | 252h | 31.5h |
| 25 | 1.4.1 | Interim Report |  | 4d | 2018-04-04 | 2018-04-10 |  |  |  | 2018-04-04 | 2018-04-10 | 4d | 1d | 0d |  | Damien [90%]; Maarten [90%]; Maria [90%]; Moustafa [90%]; Wouter [90%] | 126h |  |
| 26 | 1.4.2 | Interim Presentation |  | 2d | 2018-04-10 A | 2018-04-12 | 25 | 50% | 1d | 2018-04-10 | 2018-04-12 | 2d | 0.5d | 0d |  | Damien [90%]; Maarten [90%]; Maria [90%]; Moustafa [90%]; Wouter [90%] | 63h | 31.5h |
| 27 | 1.4.3 | Upload Interim Deliverables & Send S&P Assessment |  | 1d | 2018-04-12 | 2018-04-13 | 26 |  |  | 2018-04-12 | 2018-04-13 | 1d | 0.5d | 0d | 2018-04-13 | Damien [90%]; Maarten [90%]; Maria [90%]; Moustafa [90%]; Wouter [90%] | 31.5h |  |
| 28 | 1.4.4 | Interim Presentation Session |  | 1d | 2018-04-13 | 2018-04-16 | 27 |  |  | 2018-04-13 | 2018-04-16 | 1d | 3.5d |  | 2018-04-19 | Damien [90%]; Maarten [90%]; Maria [90%]; Moustafa [90%]; Wouter [90%] | 31.5h |  |
| 29 | 1.5 | Selection of Local Providers & Final List of Materials & Components |  | 1d | 2018-04-16 | 2018-04-17 | 24 |  |  | 2018-04-16 | 2018-04-17 | 1d | 4.5d | 0d | 2018-04-23 | Damien [90%]; Maarten [90%]; Maria [90%]; Moustafa [90%]; Wouter [90%] | 31.5h |  |

| ID | WBS | Task | Type | Duration | Start | Finish | Predecessors | Baseline start | Baseline finish | Baseline duration | Total slack | Free slack | Constraint | Deadline | Resources | Work |
| --- | --- | --- | --- | --- | --- | --- | --- | --- | --- | --- | --- | --- | --- | --- | --- | --- |
| 30 | 1.6 | **Construction** |  | 21d | 2018-04-17 | 2018-05-23 | 29 | 2018-04-17 | 2018-05-23 | 21d | 3.5d | 0d |  | 2018-06-01 |  | 478.45h |
| 31 | 1.6.1 | **Hardware** |  | 21d | 2018-04-17 | 2018-05-23 |  | 2018-04-17 | 2018-05-23 | 21d | 3.5d |  |  |  |  | 301h |
| 32 | 1.6.1.1 | Sensors |  | 5d | 2018-04-17 | 2018-04-24 |  | 2018-04-17 | 2018-04-24 | 5d | 19.5d |  |  |  | Damien [25%]; Moustafa [25%] | 17.5h |
| 33 | 1.6.1.2 | Base |  | 10d | 2018-04-17 | 2018-05-01 |  | 2018-04-17 | 2018-05-01 | 10d | 14.5d |  |  |  | Maarten [45%]; Maria [45%]; Wouter [45%] | 94.5h |
| 34 | 1.6.1.3 | Case |  | 20d | 2018-04-18 | 2018-05-23 |  | 2018-04-18 | 2018-05-23 | 20d | 3.5d |  |  |  | Maarten [45%]; Maria [45%]; Wouter [45%] | 189h |
| 35 | 1.6.2 | **Software** |  | 20d | 2018-04-17 | 2018-05-22 |  | 2018-04-17 | 2018-05-22 | 20d | 4.5d |  |  |  |  | 177.45h |
| 36 | 1.6.2.1 | Arduino Code |  | 20d | 2018-04-17 | 2018-05-22 |  | 2018-04-17 | 2018-05-22 | 20d | 4.5d |  |  |  | Damien [65%]; Moustafa [65%] | 177.45h |
| 37 | 1.7 | Refined Report | milestone | 0d | 2018-02-28 | 2018-02-28 |  | 2018-02-28 | 2018-02-28 | 0d | 41d |  |  | 2018-05-02 | Damien; Maarten; Maria; Moustafa; Wouter |  |
| 38 | 1.8 | **Functional Tests & Results** |  | 4d | 2018-05-23 | 2018-05-29 | 30 | 2018-05-23 | 2018-05-29 | 4d | 3.5d |  |  | 2018-06-04 |  | 77h |
| 39 | 1.8.1 | Unit Testing |  | 2d | 2018-05-23 | 2018-05-25 |  | 2018-05-23 | 2018-05-25 | 2d | 3.5d | 0d |  |  | Damien [90%]; Moustafa [90%] | 25.2h |
| 40 | 1.8.2 | Product Testing |  | 2d | 2018-05-25 | 2018-05-29 | 39 | 2018-05-25 | 2018-05-29 | 2d | 4.5d |  |  |  | Damien [10%]; Maarten [90%]; Maria [90%]; Wouter [90%]; Moustafa [10%] | 40.6h |
| 41 | 1.8.3 | Corrections |  | 2d | 2018-05-25 | 2018-05-29 | 39 | 2018-05-25 | 2018-05-29 | 2d | 3.5d | 0d |  |  | Damien [80%]; Moustafa [80%] | 11.2h |
| 42 | 1.9 | **Upload final report** |  | 52d | 2018-04-02 | 2018-06-19 | 11 | 2018-04-02 | 2018-06-19 | 52d | -1d | 0d |  |  |  | 313.6h |
| 43 | 1.9.1 | Write Report |  | 49d | 2018-04-02 | 2018-06-14 |  | 2018-04-02 | 2018-06-14 | 49d | -1d | 0d | start no earlier than 2018-04-02 |  | Damien [10%]; Maarten [10%]; Maria [10%]; Moustafa [10%]; Wouter [10%] | 169.75h |
| 44 | 1.9.2 | Upload Report | milestone | 0d | 2018-06-15 | 2018-06-15 | 43 | 2018-06-15 | 2018-06-15 | 0d | 0d |  | must finish on 2018-06-15 |  | Damien; Maarten; Maria; Moustafa; Wouter |  |
| 45 | 1.9.3 | Paper |  | 7.5d | 2018-06-01 | 2018-06-12 | 41 | 2018-06-01 | 2018-06-12 | 7.5d | 4d |  |  |  | Damien [10%]; Maarten [10%]; Maria [10%]; Moustafa [70%]; Wouter [10%] | 57.75h |
| 47 | 1.9.4 | Video |  | 3d | 2018-06-08 | 2018-06-13 | 41 | 2018-06-08 | 2018-06-13 | 3d | 3.5d |  |  |  | Damien [10%]; Maarten [10%]; Maria [70%]; Moustafa [10%]; Wouter [10%] | 23.1h |
| 48 | 1.9.5 | Evaluation |  | 1d | 2018-05-29 | 2018-05-30 | 41 | 2018-05-29 | 2018-05-30 | 1d | 13.5d |  |  |  | Damien [10%]; Maarten [10%]; Maria [10%]; Moustafa [10%]; Wouter [70%] | 3.85h |
| 49 | 1.9.6 | Presentation |  | 3d | 2018-06-15 | 2018-06-19 | 43 | 2018-06-15 | 2018-06-19 | 3d | -1d | 0d |  |  | Damien [10%]; Maarten [70%]; Maria [10%]; Moustafa [10%]; Wouter [10%] | 23.1h |
| 50 | 1.9.7 | Demonstration |  | 1d | 2018-05-29 | 2018-05-30 | 41 | 2018-05-29 | 2018-05-30 | 1d | 13.5d |  |  |  | Damien [10%]; Maarten [10%]; Maria [70%]; Moustafa [10%]; Wouter [10%] | 7.7h |
| 51 | 1.9.8 | Manual |  | 3d | 2018-05-29 | 2018-06-01 | 41 | 2018-05-29 | 2018-06-01 | 3d | 11.5d |  |  |  | Damien [70%]; Maarten [10%]; Maria [10%]; Moustafa [10%]; Wouter [10%] | 3.85h |
| 52 | 1.9.9 | Upload Other | milestone | 0d | 2018-06-18 | 2018-06-18 | 45, 47, 48, 49, 50, 51 | 2018-06-18 | 2018-06-18 | 0d | -1d | 0d | must finish on 2018-06-18 |  | Damien; Maarten; Maria; Moustafa; Wouter |  |
| 53 | 1.10 | Final Presentation & Assessment | milestone | 0d | 2018-02-28 | 2018-02-28 |  | 2018-02-28 | 2018-02-28 | 0d | 70d |  |  | 2018-06-21 | Damien; Maarten; Maria; Moustafa; Wouter |  |
| 54 | 1.11 | EPS@ISEP 2018 Closing & Certificate Awarding Session: Hand-in Prototype, CD, printed Report + Poster | milestone | 0d | 2018-02-28 | 2018-02-28 |  | 2018-02-28 | 2018-02-28 | 0d | 70d |  |  | 2018-06-28 | Damien; Maarten; Maria; Moustafa; Wouter |  |
